# Remodelacion completa HOTEL BOUTIQUE

Schedule from MS Project, 2025-02-07 to 2025-04-28.

## Calendars

- Estándar: Mon-Fri 09:00-13:00, 15:00-19:00; Sat-Sun off.

## Resources

| Resource |
| --- |
| Gestor de Proyecto |
| Cliente |
| Diseñador Principal |
| Asistente de Diseño |
| Coordinador de compras |
| Equipo de obra |
| Equipo de decoracion |

## Schedule

| ID | WBS | Task | Type | Duration | Start | Finish | Predecessors | Total slack | Constraint | Resources | Work |
| --- | --- | --- | --- | --- | --- | --- | --- | --- | --- | --- | --- |
| 1 | 1 | **Planificación y Definición de Alcance** |  | 6d | 2025-02-07 | 2025-02-14 |  | 0d |  |  | 96h |
| 2 | 1.1 | Reunión inicial con el cliente |  | 1d | 2025-02-07 | 2025-02-07 |  | 0d |  | Cliente; Gestor de Proyecto | 16h |
| 3 | 1.2 | **Definir requerimientos y presupuesto del proyecto** |  | 5d | 2025-02-10 | 2025-02-14 |  | 0d |  |  | 80h |
| 4 | 1.2.1 | Identificar necesidades de diseño en habitaciones y áreas comunes |  | 2d | 2025-02-10 | 2025-02-11 | 2 | 0d |  | Cliente; Gestor de Proyecto | 32h |
| 5 | 1.2.2 | Evaluar presupuesto disponible |  | 3d | 2025-02-12 | 2025-02-14 | 4 | 0d |  | Cliente; Gestor de Proyecto | 48h |
| 6 | 2 | **Diseño y Propuesta** |  | 8d | 2025-02-17 | 2025-02-26 |  | 0d |  |  | 160h |
| 7 | 2.1 | **Desarrollo del concepto de diseño** |  | 8d | 2025-02-17 | 2025-02-26 |  | 0d |  |  | 160h |
| 8 | 2.1.1 | Crear moodboards y propuesta de paleta de colores |  | 2d | 2025-02-17 | 2025-02-18 | 5 | 0d |  | Asistente de Diseño; Diseñador Principal | 32h |
| 9 | 2.1.2 | Desarrollar planos preliminares y presentación de distribución de mobiliario |  | 8d | 2025-02-17 | 2025-02-26 | 8SS | 0d |  | Asistente de Diseño; Diseñador Principal | 128h |
| 10 | 3 | Reunion aprobacion propuesta de diseño | milestone, manual | 0d | 2025-03-03 | 2025-03-03 | 6 |  |  |  |  |
| 11 | 4 | **Adquisición y Contratación** |  | 15d | 2025-02-27 | 2025-03-19 |  | 0d |  |  | 120h |
| 12 | 4.1 | Selección y adquisición de materiales y mobiliario |  | 15d | 2025-02-27 | 2025-03-19 | 9 | 0d |  | Coordinador de compras | 120h |
| 13 | 5 | **Remodelación de Habitaciones** |  | 10d | 2025-03-20 | 2025-04-02 |  | 0d |  |  | 48h |
| 14 | 5.1 | Preparación de las habitaciones para la renovación |  | 3d | 2025-03-20 | 2025-03-24 | 12 | 0d |  | Equipo de obra; Coordinador de compras | 48h |
| 15 | 5.2 | Instalación de revestimientos y pintura |  | 7d | 2025-03-25 | 2025-04-02 | 14 | 0d |  |  |  |
| 16 | 6 | **Reuniones semanales** |  | 16d | 2025-04-04 | 2025-04-25 |  | 0d |  |  |  |
| 17 | 6.1 | Reuniones semanales 1 | manual | 1d | 2025-04-04 | 2025-04-04 |  |  | start no earlier than 2025-04-04 |  |  |
| 18 | 6.2 | Reuniones semanales 2 | manual | 1d | 2025-04-11 | 2025-04-11 |  |  | start no earlier than 2025-04-11 |  |  |
| 19 | 6.3 | Reuniones semanales 3 | manual | 1d | 2025-04-18 | 2025-04-18 |  |  | start no earlier than 2025-04-18 |  |  |
| 20 | 6.4 | Reuniones semanales 4 | manual | 1d | 2025-04-25 | 2025-04-25 |  |  | start no earlier than 2025-04-25 |  |  |
| 21 | 7 | **Remodelación de Áreas Comunes** |  | 10d | 2025-04-03 | 2025-04-16 |  | 0d |  |  | 160h |
| 22 | 7.1 | Diseño e instalación de recepción y áreas comunes |  | 10d | 2025-04-03 | 2025-04-16 | 15 | 0d |  | Diseñador Principal; Equipo de obra | 160h |
| 23 | 8 | **Implementación de Decoración y Acabados** |  | 5d | 2025-04-17 | 2025-04-23 |  | 0d |  |  | 80h |
| 24 | 8.1 | Colocación de muebles y decoraciones en habitaciones |  | 5d | 2025-04-17 | 2025-04-23 | 22 | 0d |  | Asistente de Diseño; Equipo de decoracion | 80h |

| ID | WBS | Task | Duration | Start | Finish | Predecessors | Total slack | Resources | Work |
| --- | --- | --- | --- | --- | --- | --- | --- | --- | --- |
| 25 | 9 | **Revisión Final y Entrega** | 3d | 2025-04-24 | 2025-04-28 |  | 0d |  | 32h |
| 26 | 9.1 | Inspección y corrección de detalles | 2d | 2025-04-24 | 2025-04-25 | 24 | 0d | Diseñador Principal; Gestor de Proyecto | 32h |
| 27 | 9.2 | Presentación final y entrega al cliente | 1d | 2025-04-28 | 2025-04-28 | 26 | 0d |  |  |
